# Tr Sokolnice - soubor staveb Sokolnice I

Schedule from MS Project, 2020-02-16 to 2020-11-22.
Elektran,s.r.o.

## Calendars

- Celý týden: Mon-Sun 08:00-12:00, 13:00-17:00.

## Schedule

| ID | WBS | Task | Duration | Start | Finish | Predecessors | Total slack | Free slack | Constraint | Deadline |
| --- | --- | --- | --- | --- | --- | --- | --- | --- | --- | --- |
| 1 | 1 | Příprava stavby, zařízení staveniště | 14d | 2020-02-16 | 2020-03-01 | 3SF-1d | 264d |  |  |  |
| 2 | 2 | **Příprava stavby - provizoria, bypassové pole V604-T101** | 90d | 2020-03-02 | 2020-05-30 |  | -5149d | 0d |  |  |
| 3 | 2.1 | Stavební práce bypass | 30d | 2020-03-02 | 2020-03-31 |  | -5149d | 0d | start no earlier than 2020-03-02 |  |
| 4 | 2.2 | Výměna centrální jednotky skříně SICAM - zařízení DŘT na TNS Javlunkov, včetně odzkoušení | 2d | 2020-03-03 | 2020-03-04 | 3SS+1d | 263d |  |  |  |
| 5 | 2.3 | Stavební práce - základy pro domek ochran | 40d | 2020-03-02 | 2020-04-10 | 3SS | 183d | 0d |  |  |
| 6 | 2.4 | Ustavení montového domku ochran na základ | 10d | 2020-05-11 | 2020-05-20 | 5FS+30d | 183d |  |  |  |
| 7 | 2.5 | Instalace HOK bypass do linky | 7d | 2020-04-01 | 2020-04-07 | 3 | 226d |  |  |  |
| 8 | 2.6 | Instalace POK bypass | 14d | 2020-04-01 | 2020-04-14 | 3 | -5149d | 0d | start no earlier than 2009-03-31 | 2006-03-10 |
| 9 | 2.7 | Instalace přístrojů a propojení v poli bypassu | 21d | 2020-04-15 | 2020-05-05 | 8 | 0d |  |  |  |
| 10 | 2.8 | Uzemnění bypassového pole | 7d | 2020-04-29 | 2020-05-05 | 9FF | 198d |  |  |  |
| 11 | 2.9 | Kabelové trasy pro bypassové pole | 7d | 2020-05-06 | 2020-05-12 | 9 | 0d |  |  |  |
| 12 | 2.10 | Stavební práce, propojení na T101 | 14d | 2020-04-29 | 2020-05-12 | 11FF | 0d |  |  |  |
| 13 | 2.11 | Kabelové trasy pro přeložky VN | 14d | 2020-04-29 | 2020-05-12 | 12SS | 187d | 0d |  |  |
| 14 | 2.12 | Přeústění kabelů VN (propojení ČEZ-D, SŽDC), zkoušky, zprovoznění | 4d | 2020-05-13 | 2020-05-16 | 13 | 190d |  |  |  |
| 15 | 2.13 | Demontáž přístrojů AEA01 v prostoru bypassu | 3d | 2020-05-13 | 2020-05-15 | 12 | 0d |  |  |  |
| 16 | 2.14 | Přepojení bypassu na T101, odpojení V604 od portálu v R110 | 11d | 2020-05-16 | 2020-05-26 | 15 | 0d |  |  |  |
| 17 | 2.15 | Funkční zkoušky bypassového pole | 3d | 2020-05-27 | 2020-05-29 | 16 | 0d |  |  |  |
| 18 | 2.16 | Přepojení a zprovoznění V 604 na bypass | 1d | 2020-05-30 | 2020-05-30 | 17 | 0d |  |  |  |
| 19 | 3 | **R110 kV 1. etapa** | 127d | 2020-05-31 | 2020-10-04 |  | 0d |  |  |  |
| 20 | 3.1 | Stavební instalace domku ochran | 28d | 2020-05-31 | 2020-06-27 | 18 | 28d | 0d |  |  |
| 21 | 3.2 | Montáž technologie v domku ochran | 35d | 2020-07-26 | 2020-08-29 | 20FS+28d | 28d |  |  |  |
| 22 | 3.3 | Odpojení V603 na portálu před rozvodnou, přepojení KZL | 1d | 2020-05-31 | 2020-05-31 | 18 | 0d |  |  |  |
| 23 | 3.4 | Přeložky vedení 22kV | 7d | 2020-06-01 | 2020-06-07 | 22 | 168d |  |  |  |
| 24 | 3.5 | Demontáž lanových přetahů v R110 | 6d | 2020-06-01 | 2020-06-06 | 22 | 0d |  |  |  |
| 25 | 3.6 | Demontáž přístrojů a OK v R110kV | 7d | 2020-06-07 | 2020-06-13 | 24 | 0d |  |  |  |
| 26 | 3.7 | Demontáž hlavních žb konstrukcí | 3d | 2020-06-14 | 2020-06-16 | 25 | 0d |  |  |  |
| 27 | 3.8 | Demolice základů v R110 | 14d | 2020-06-17 | 2020-06-30 | 26 | 0d |  |  |  |
| 28 | 3.9 | Odvodnění R110 | 14d | 2020-07-15 | 2020-07-28 | 29FF | 117d |  |  |  |
| 29 | 3.10 | Nové základové patky | 28d | 2020-07-01 | 2020-07-28 | 27 | 0d |  |  |  |
| 30 | 3.11 | Instalace nových HOK - portály vedení V603 a V 604 | 7d | 2020-07-29 | 2020-08-04 | 29 | 110d |  |  |  |
| 31 | 3.12 | Instalace nových POK | 21d | 2020-07-29 | 2020-08-18 | 29 | 0d |  |  |  |
| 32 | 3.13 | Instalace přístrojů V603, V604 a T102 | 35d | 2020-08-08 | 2020-09-11 | 31SS+10d | 0d |  |  |  |
| 33 | 3.14 | Silová propojení V603, V604 a T102 | 14d | 2020-09-12 | 2020-09-25 | 32 | 1d |  |  |  |
| 34 | 3.15 | Uzemnění R110 | 21d | 2020-07-29 | 2020-08-18 | 31FF | 39d |  |  |  |
| 35 | 3.16 | Kabelové trasy, zapojení V603, V604 a T102 | 15d | 2020-09-12 | 2020-09-26 | 32 | 0d |  |  |  |
| 36 | 3.17 | Funkční zkoušky V603 a T102 | 7d | 2020-09-27 | 2020-10-03 | 33, 34, 35, 21 | 0d |  |  |  |
| 37 | 3.18 | Přepojení a zprovoznění vedení V603 a T102, přepojení KZL | 1d | 2020-10-04 | 2020-10-04 | 36 | 0d |  |  |  |

Notes:
- 14: Musí probíhat za provozu T101 i T102

| ID | WBS | Task | Type | Duration | Start | Finish | Predecessors | Total slack | Free slack |
| --- | --- | --- | --- | --- | --- | --- | --- | --- | --- |
| 38 | 4 | **R110 kV 2. etapa** |  | 49d | 2020-10-05 | 2020-11-22 |  | 0d |  |
| 39 | 4.1 | Demontáž bypasového připojení T101 |  | 4d | 2020-10-05 | 2020-10-08 | 37 | 0d |  |
| 40 | 4.2 | Demontáž silového propojení v poli bypassu |  | 2d | 2020-10-09 | 2020-10-10 | 39 | 0d |  |
| 41 | 4.3 | Demontáž přístrojů v poli bypassu |  | 10d | 2020-10-11 | 2020-10-20 | 40 | 0d |  |
| 42 | 4.4 | Instalace přístrojů v poli T101 |  | 15d | 2020-10-11 | 2020-10-25 | 41SS | 0d |  |
| 43 | 4.5 | Silová propojení T101 |  | 3d | 2020-10-26 | 2020-10-28 | 42 | 4d |  |
| 44 | 4.6 | Kabelové trasy, zapojení pole T101 |  | 7d | 2020-10-26 | 2020-11-01 | 42 | 0d |  |
| 45 | 4.7 | Funkční zkoušky V604, T101 |  | 5d | 2020-11-02 | 2020-11-06 | 44, 43 | 0d |  |
| 46 | 4.8 | Přepojení a zprovoznění vedení V604 a T101, poz. |  | 1d | 2020-11-07 | 2020-11-07 | 45 | 0d |  |
| 47 | 4.9 | Demontáž POK v poli bypassu |  | 5d | 2020-11-08 | 2020-11-12 | 46 | 7d | 0d |
| 48 | 4.10 | Měření HUS, krokových a dotykových napětí |  | 1d | 2020-11-15 | 2020-11-15 | 47FS+2d | 7d | 0d |
| 49 | 4.11 | Dokončovací práce |  | 15d | 2020-11-08 | 2020-11-22 | 46 | 0d |  |
| 50 | 5 | **Sekundární technika** |  | 209d | 2020-03-02 | 2020-09-26 |  | 57d |  |
| 51 | 5.1 | Stavební příprava domku |  | 120d | 2020-03-02 | 2020-06-29 | 3SS | 76d | 0d |
| 52 | 5.2 | Instalace zařízení sekundární techniky pro R110 |  | 30d | 2020-06-30 | 2020-07-29 | 51 | 76d | 0d |
| 53 | 5.3 | Zapojení sekundárních obvodů |  | 20d | 2020-07-30 | 2020-08-18 | 52 | 76d | 19d |
| 54 | 5.4 | Zkoušky a zprovoznění |  | 20d | 2020-09-07 | 2020-09-26 | 35FF, 53 | 57d |  |
| 55 | 6 | **Ostatní zařízení** |  | 30d | 2020-10-24 | 2020-11-22 |  | 0d |  |
| 56 | 6.1 | Okružní komunikace |  | 30d | 2020-10-24 | 2020-11-22 | 49FF | 0d |  |
| 57 | 6.2 | TSFO |  | 7d | 2020-11-07 | 2020-11-13 | 45 | 9d |  |
| 58 | 6.3 | Konečná úprava terénu |  | 15d | 2020-11-08 | 2020-11-22 | 49FF | 0d |  |
| 59 | 7 | Ukončení stavby | milestone | 0d | 2020-11-22 | 2020-11-22 | 38, 50, 55 | 0d |  |
| 61 | 8 | **Výluky R110 a transformace 110 a 22kV** |  | 258d | 2020-03-03 | 2020-11-15 |  | 7d |  |
| 62 | 8.1 | Výluka DŘT - místní obsluha |  | 2d | 2020-03-03 | 2020-03-04 | 4SS | 263d |  |
| 63 | 8.2 | 12h - Přepojení V604 na bypass, V604 VOZ, V603 VOZ p.č. 1h |  | 1d | 2020-05-30 | 2020-05-30 | 18SS | 176d |  |
| 64 | 8.3 | 12h - Rozpojení přeponek V603, V603 VOZ, V604 VOZ p.č. 1h |  | 1d | 2020-05-31 | 2020-05-31 | 22SS | 47d | 0d |
| 65 | 8.4 | 4h - Demontáž HK, V603 v R110 VOZ, V604 VOZ p.č. 1h |  | 1d | 2020-06-14 | 2020-06-14 | 26SS | 161d |  |
| 66 | 8.5 | 12h - Připojení V603 (přeponky), V603 VOZ, V604 VOZ p.č. 4h |  | 1d | 2020-10-04 | 2020-10-04 | 37SS | 20d | 0d |
| 67 | 8.6 | 12h - Napojení V604 na portál, V603 VOZ - PČ 1h, V604 VOZ |  | 1d | 2020-11-07 | 2020-11-07 | 46SS | 15d |  |
| 68 | 8.7 | V603 - odpojeno na přeponce, v TNS Jablunkov VOZ |  | 129d | 2020-05-31 | 2020-10-06 | 64SS | 47d |  |
| 69 | 8.8 | V604 - odpojeno na přeponce, v TNS Jablunkov VOZ |  | 29d | 2020-10-05 | 2020-11-02 | 66 | 20d |  |
| 70 | 8.9 | V604 nebo V603 uvolněno pro měření krokových napětí |  | 1d | 2020-11-15 | 2020-11-15 | 48SS | 7d |  |

Notes:
- 46: Vypnutí V603 i V604 - 12hod, pohotovostní čas V603 1 hod.
- 63: schémata 2-3-4
- 64: schéma 4-5-6
- 65: schéma 6-7-6
- 66: schéma 6-8-9
- 67: schéma 10-11-12
- 68: schéma 6
- 69: schéma 10
